# 2-2

Schedule from MS Project, 2023-09-14 to 2024-01-16, 2 hours a day, costs in €, A marks actual dates.
Universite Clermont Auvergne

## Calendars

- SAE: Mon-Fri 08:00-10:00; Sat-Sun off.

## Resources

| Resource | Rate |
| --- | --- |
| A_PE | 20 |
| K_MO | 20 |
| P_LE | 20 |
| D_DA | 20 |
| A_PI | 20 |

## Schedule

| ID | WBS | Task | Duration | Start | Finish | Predecessors | Complete | Remaining | Actual start | Total slack | Free slack | Resources | Work | Actual work | Cost | Actual cost |
| --- | --- | --- | --- | --- | --- | --- | --- | --- | --- | --- | --- | --- | --- | --- | --- | --- |
| 1 | 1 | **Étude de courbes de fréquence cardiaque** | 88.48d? | 2023-09-14 A | 2024-01-16 |  | 42% | 51.3d? |  | 0d |  |  | 734.1h | 302.99h | 14,682 | 6,059.8 |
| 2 | 1.1 | **1 - Management de projet** | 85.81d | 2023-09-14 A | 2024-01-12 |  | 69% | 26.69d |  | 2.67d |  |  | 184.5h | 136.1h | 3,690 | 2,722 |
| 3 | 1.1.1 | **1.1 - Recueil de besoins** | 38.5d | 2023-09-14 A | 2023-11-07 |  | 88% | 4.56d |  | 49.98d |  |  | 87h | 80.5h | 1,740 | 1,610 |
| 4 | 1.1.1.1 | 1.1.1 - Présentation general du projet | 2h | 2023-09-18 A | 2023-09-18 A | 13 | 100% |  |  |  |  | A_PE | 2h | 2h | 40 | 40 |
| 5 | 1.1.1.2 | 1.1.2 - Compte rendu 1 | 3h | 2023-09-22 A | 2023-09-22 A | 4, 12 | 100% |  |  |  |  | A_PE; A_PI; D_DA; K_MO; P_LE | 7h | 7h | 140 | 140 |
| 6 | 1.1.1.3 | 1.1.3 - Compte rendu 1 (v2) | 5h | 2023-10-05 A | 2023-10-06 A | 7 | 100% |  |  |  |  | A_PE; A_PI; D_DA; K_MO; P_LE | 25h | 25h | 500 | 500 |
| 7 | 1.1.1.4 | 1.1.4 - Backlog (users stories) | 5h | 2023-10-02 A | 2023-10-04 A | 5 | 100% |  |  |  |  | D_DA; P_LE | 10h | 10h | 200 | 200 |
| 8 | 1.1.1.5 | 1.1.5 - Compte Rendu (V2) | 7h | 2023-10-03 A | 2023-10-06 A | 5 | 100% |  |  |  |  | A_PE | 7h | 7h | 140 | 140 |
| 9 | 1.1.1.6 | 1.1.6 - Compte rendu 2 (V2) | 5h | 2023-10-06 A | 2023-10-10 A | 6 | 100% |  |  |  |  | A_PE | 5h | 5h | 100 | 100 |
| 10 | 1.1.1.7 | 1.1.7 - Rapport BDD | 2h | 2023-11-07 A | 2023-11-07 A | 37 | 100% |  |  |  |  | A_PE; P_LE; D_DA; K_MO; A_PI | 10h | 10h | 200 | 200 |
| 11 | 1.1.1.8 | **1.1.5 - Rendez vous** | 7d | 2023-09-14 A | 2023-09-25 |  | 50% | 3.5d |  | 81.48d |  |  | 21h | 14.5h | 420 | 290 |
| 12 | 1.1.1.8.1 | 1.1.5.1 - Avec le tuteur | 4.5h | 2023-09-18 A | 2023-09-25 |  | 78% | 1h |  | 81.73d |  | A_PE; A_PI; D_DA; K_MO; P_LE | 16h | 13.5h | 320 | 270 |
| 13 | 1.1.1.8.2 | 1.1.5.2 - Avec le client | 4.5h | 2023-09-14 | 2023-09-25 |  | 22% | 3.5h | 2023-09-15 | 19.3d | 14.5d | A_PE; A_PI; D_DA; K_MO; P_LE | 5h | 1h | 100 | 20 |
| 14 | 1.1.2 | **1.2 - Organisation du travail en équipe** | 10d | 2023-09-15 A | 2023-09-28 A |  | 100% |  |  |  |  |  | 8h | 8h | 160 | 160 |
| 15 | 1.1.2.1 | 1.2.1 - Mise en place du kanban | 2h | 2023-09-15 A | 2023-09-28 A |  | 100% |  |  |  |  | A_PE; D_DA | 2h | 2h | 40 | 40 |
| 16 | 1.1.2.2 | 1.2.2 - Mise en place du codefirst | 3h | 2023-09-25 A | 2023-09-26 A |  | 100% |  |  |  |  | D_DA | 3h | 3h | 60 | 60 |
| 17 | 1.1.2.3 | 1.2.3 - Mise en place du notion | 2h | 2023-09-15 A | 2023-09-15 A |  | 100% |  |  |  |  | D_DA; A_PE | 2h | 2h | 40 | 40 |
| 18 | 1.1.2.4 | 1.2.4 - Mise en place du discord | 0.5h | 2023-09-15 A | 2023-09-15 A |  | 100% |  |  |  |  | A_PE; A_PI | 1h | 1h | 20 | 20 |
| 19 | 1.1.3 | **1.3 - Planification du projet** | 16.5d | 2023-09-20 A | 2023-10-12 A |  | 100% |  |  |  |  |  | 31h | 31h | 620 | 620 |
| 20 | 1.1.3.1 | 1.3.1 - WBS | 6h | 2023-09-20 A | 2023-09-22 A | 5 | 100% |  |  |  |  | A_PE; K_MO | 10h | 10h | 200 | 200 |
| 21 | 1.1.3.2 | 1.3.2 - GANTT prévisionnel | 17h | 2023-09-29 A | 2023-10-12 A | 20 | 100% |  |  |  |  | A_PE; P_LE | 17h | 17h | 340 | 340 |
| 22 | 1.1.3.3 | 1.3.3 - PERT | 4h | 2023-10-09 A | 2023-10-11 A | 21 | 100% |  |  |  |  | A_PE; P_LE | 4h | 4h | 80 | 80 |
| 23 | 1.1.4 | **1.4 - Suivi de projet** | 82.31d | 2023-09-20 A | 2024-01-12 |  | 22% | 64.01d |  | 2.67d |  |  | 58.5h | 16.6h | 1,170 | 332 |
| 24 | 1.1.4.1 | 1.4.1 - Indicateurs de suivi de projet | 3h | 2023-11-22 A | 2023-11-23 | 22 | 70% | 0.9h |  | 37.98d |  | D_DA; A_PE | 3h | 2.1h | 60 | 42 |
| 25 | 1.1.4.2 | 1.4.2 - Préparation des vidéos | 8h | 2024-01-01 | 2024-01-12 | 26 |  |  |  | 2.67d |  | A_PE; A_PI; D_DA; K_MO; P_LE | 15h |  | 300 |  |
| 26 | 1.1.4.3 | 1.4.3 - Préparation des rapports globaux | 8.2h | 2023-12-19 | 2024-01-01 | 67 |  |  |  | 2.67d | 0d | A_PE; A_PI; D_DA; K_MO; P_LE | 10h |  | 200 |  |
| 27 | 1.1.4.4 | 1.4.4 - Préparation oral 1 | 5h | 2023-11-14 A | 2023-11-24 A | 24 | 100% |  |  |  |  | A_PE; A_PI; D_DA; K_MO; P_LE | 13h | 13h | 260 | 260 |
| 28 | 1.1.4.5 | 1.4.5 - Préparation oral 2 | 12.48h | 2023-12-07 | 2024-01-10 | 27 |  |  |  | 4.67d |  | A_PE; A_PI; K_MO; P_LE | 15h |  | 300 |  |
| 29 | 1.1.4.6 | 1.4.6 - GANTT réel | 1.5h | 2023-11-14 A | 2023-12-19 | 67 | 67% | 0.5h |  | 20.16d |  | A_PI; A_PE | 2h | 1h | 40 | 20 |
| 30 | 1.1.4.7 | 1.4.7 - Graphe de compétence | 0.5h | 2023-09-20 A | 2023-09-20 A |  | 100% |  |  |  |  | K_MO | 0.5h | 0.5h | 10 | 10 |

| ID | WBS | Task | Type | Duration | Start | Finish | Predecessors | Complete | Remaining | Total slack | Free slack | Resources | Work | Actual work | Cost | Actual cost |
| --- | --- | --- | --- | --- | --- | --- | --- | --- | --- | --- | --- | --- | --- | --- | --- | --- |
| 31 | 1.2 | **2 - Développement** |  | 81.48d? | 2023-09-25 A | 2024-01-16 |  | 34% | 53.88d? | 0d |  |  | 549.6h | 166.89h | 10,992 | 3,337.8 |
| 32 | 1.2.1 | **2.1 - Conception** |  | 36.58d | 2023-09-25 A | 2023-11-15 |  | 50% | 18.23d | 44.9d |  |  | 133h | 74.64h | 2,660 | 1,492.8 |
| 33 | 1.2.1.1 | 2.1.1 - Communication (reseaux) |  | 11.2h | 2023-10-06 A | 2023-11-15 | 34 | 11% | 10h | 3.75d | 0d | A_PE; P_LE | 20h | 1.2h | 400 | 24 |
| 34 | 1.2.1.2 | 2.1.2 - Architecture |  | 12h | 2023-09-29 A | 2023-11-08 | 35 | 7% | 11.16h | 0d |  | A_PE; D_DA | 14h | 0.84h | 280 | 16.8 |
| 35 | 1.2.1.3 | 2.1.3 - Diagramme de classes |  | 14.02h | 2023-09-25 A | 2023-10-30 | 37 | 34% | 9.22h | 0.37d | 0d | A_PE; A_PI; D_DA | 26h | 11.2h | 520 | 224 |
| 36 | 1.2.1.4 | 2.1.4 - Maquettes |  | 12h | 2023-09-28 A | 2023-10-04 A | 5 | 100% |  |  |  | A_PI | 12h | 12h | 240 | 240 |
| 37 | 1.2.1.5 | 2.1.5 - MCD & MLD |  | 8h | 2023-10-16 A | 2023-10-19 A | 36 | 100% |  |  |  | D_DA; P_LE; K_MO; A_PI; A_PE | 32h | 32h | 640 | 640 |
| 38 | 1.2.1.6 | 2.1.6 - Diagramme de cas d'utilisation |  | 10h | 2023-10-16 A | 2023-10-24 | 13 | 80% | 2h | 11.56d | 3.56d | K_MO; A_PE | 12h | 10h | 240 | 200 |
| 39 | 1.2.1.7 | 2.1.7 - Charte graphique |  | 16h | 2023-10-10 A | 2023-11-03 | 9 | 40% | 9.6h | 52.37d |  | A_PI | 16h | 6.4h | 320 | 128 |
| 40 | 1.2.1.8 | 2.1.8 - Logo |  | 1h | 2023-10-20 A | 2023-10-20 A |  | 100% |  |  |  | D_DA | 1h | 1h | 20 | 20 |
| 41 | 1.2.2 | **2.2 - Client Web et Mobile** |  | 45.58d? | 2023-10-27 A | 2024-01-01 |  | 15% | 38.6d? | 11.91d |  |  | 146.1h | 13.75h | 2,922 | 275 |
| 42 | 1.2.2.1 | 2.2.1 - Interface utilisateur client (Vues) |  | 15h? | 2023-11-06 A | 2023-12-26 | 34 | 35% | 9.75h? | 15.28d |  | A_PI | 15h | 5.25h | 300 | 105 |
| 43 | 1.2.2.2 | 2.2.2 - Gestion des données client |  | 60.67h? | 2023-11-13 | 2023-12-28 | 34 |  |  | 11.91d | 0d | A_PE; D_DA; P_LE | 117h |  | 2,340 |  |
| 44 | 1.2.2.3 | 2.2.3 - Authentification Web et Mobile client |  | 3h | 2023-12-28 | 2024-01-01 | 33, 43, 47, 48, 49, 69, 70, 71, 72, 73, 74, 75 |  |  | 11.91d |  | A_PI; K_MO; D_DA | 3h |  | 60 |  |
| 45 | 1.2.2.4 | 2.2.4 - Récupération des données de fréquence cardiaque |  | 5h | 2023-10-27 A | 2023-11-08 | 34 | 80% | 1h | 49.4d |  | A_PE | 5h | 4h | 100 | 80 |
| 46 | 1.2.2.5 | 2.2.5 - Définitions des algoritmes d'analyse de la fréquence cardiaque | milestone | 0h | 2023-11-15 | 2023-11-22 | 33 |  |  | 39.9d |  | D_DA |  |  |  |  |
| 47 | 1.2.2.6 | 2.2.6 - Mise en place Bootstrap |  | 3.6h | 2023-10-28 A | 2023-11-09 | 34, 38 | 56% | 1.6h | 46.43d | 34.51d | A_PI | 3.6h | 2h | 72 | 40 |
| 48 | 1.2.2.7 | 2.2.7 - Mise en place talwind |  | 1.5h | 2023-10-28 A | 2023-10-30 A | 34, 38 | 100% |  |  |  | A_PI | 1.5h | 1.5h | 30 | 30 |
| 49 | 1.2.2.8 | 2.2.8 - Mise en place lead PHPStorm |  | 1h | 2023-10-28 A | 2023-10-30 A | 34, 38 | 100% |  |  |  | D_DA | 1h | 1h | 20 | 20 |
| 50 | 1.2.3 | **2.3 - Web admin et monitorin** |  | 28.18d | 2023-11-28 | 2024-01-08 |  |  |  | 6.89d |  |  | 25h |  | 500 |  |
| 51 | 1.2.3.1 | 2.3.1 - Authentification admin et monitoring |  | 9.7h | 2023-12-27 | 2024-01-08 | 33 |  |  | 6.89d |  | A_PE; D_DA | 15h |  | 300 |  |
| 52 | 1.2.3.2 | 2.3.2 - Interface utilisateur admin (Vues) |  | 10h | 2023-11-28 | 2023-12-08 | 34 |  |  | 27.82d |  | A_PI | 10h |  | 200 |  |
| 53 | 1.2.4 | **2.4 - Base de données** |  | 59.31d | 2023-10-20 A | 2024-01-11 |  | 11% | 52.62d | 3.67d |  |  | 25h | 2h | 500 | 40 |
| 54 | 1.2.4.1 | 2.4.1 - Création des tables |  | 2h | 2023-10-20 A | 2023-10-20 A | 43 | 100% |  |  |  | P_LE | 2h | 2h | 40 | 40 |
| 55 | 1.2.4.2 | 2.4.2 - Ajout des données |  | 1.73h | 2023-10-23 | 2023-10-23 | 54 |  |  | 39.14d | 35.64d | A_PE; D_DA | 3h |  | 60 |  |
| 56 | 1.2.4.3 | 2.4.3 - Mise en place d'un système de backup |  | 6h | 2023-10-23 | 2023-12-12 | 54 |  |  | 3.5d | 0d | A_PE; D_DA | 12h |  | 240 |  |
| 57 | 1.2.4.4 | 2.4.4 - Création des fonctions |  | 4h | 2023-11-03 | 2023-11-28 | 54 |  |  | 35.07d |  | A_PI | 4h |  | 80 |  |
| 58 | 1.2.4.5 | 2.4.5 - Création des index |  | 4h | 2024-01-01 | 2024-01-11 | 55, 56 |  |  | 3.67d |  | A_PE; D_DA | 4h |  | 80 |  |

| ID | WBS | Task | Duration | Start | Finish | Predecessors | Complete | Remaining | Total slack | Resources | Work | Actual work | Cost | Actual cost |
| --- | --- | --- | --- | --- | --- | --- | --- | --- | --- | --- | --- | --- | --- | --- |
| 59 | 1.2.5 | **2.5 - Serveur et communication de services** | 49.9d | 2023-11-08 | 2024-01-16 |  |  |  | 0d |  | 48h |  | 960 |  |
| 60 | 1.2.5.1 | 2.5.1 - Authentification serveur | 4h | 2023-11-15 | 2023-12-29 | 33 |  |  | 3.75d | A_PI; K_MO | 4h |  | 80 |  |
| 61 | 1.2.5.2 | 2.5.2 - Stockage cloud | 3.33h | 2024-01-04 | 2024-01-05 | 60, 62 |  |  | 0d | D_DA; A_PE; A_PI | 10h |  | 200 |  |
| 62 | 1.2.5.3 | 2.5.3 - Routage | 18h | 2023-11-08 | 2024-01-04 | 34 |  |  | 0d | A_PE; A_PI; D_DA | 18h |  | 360 |  |
| 63 | 1.2.5.4 | 2.5.4 - Gestion des données serveur | 13.96h | 2024-01-05 | 2024-01-16 | 61 |  |  | 0d | A_PI; A_PE; D_DA | 16h |  | 320 |  |
| 64 | 1.2.6 | **2.6 - Integration continue et livraison continue (CI/ CD)** | 37.09d | 2023-10-27 A | 2023-12-19 |  | 16% | 31.07d | 20.41d |  | 106h | 10h | 2,120 | 200 |
| 65 | 1.2.6.1 | 2.6.1 - Tests | 44.5h | 2023-10-27 A | 2023-12-14 | 34 | 16% | 37.5h | 0d | A_PE; A_PI; D_DA; K_MO; P_LE | 78h | 7h | 1,560 | 140 |
| 66 | 1.2.6.2 | 2.6.2 - Conteneurisation et déploiement | 8h | 2023-10-27 A | 2023-12-06 | 34 | 30% | 5.6h | 29.5d | A_PE; D_DA | 8h | 2.4h | 160 | 48 |
| 67 | 1.2.6.3 | 2.6.3 - Documentations (swagger, schéma, …) | 6.67h | 2023-11-15 A | 2023-12-19 | 65 | 3% | 6.47h | 0d | A_PE; A_PI; D_DA | 20h | 0.6h | 400 | 12 |
| 68 | 1.2.7 | **2.7 Configuration** | 11d? | 2023-10-06 A | 2023-10-20 A |  | 100% |  |  |  | 66.5h | 66.5h | 1,330 | 1,330 |
| 69 | 1.2.7.1 | 2.6.1 - Installation Twig | 0.5h | 2023-10-06 A | 2023-10-06 A | 34 | 100% |  |  | A_PI | 0.5h | 0.5h | 10 | 10 |
| 70 | 1.2.7.2 | 2.6.2 - Bootstrap | 2h | 2023-10-06 A | 2023-10-06 A | 34 | 100% |  |  | A_PI | 2h | 2h | 40 | 40 |
| 71 | 1.2.7.3 | 2.6.3 - PHP Unite | 10h | 2023-10-11 A | 2023-10-16 A | 43 | 100% |  |  | D_DA; P_LE | 20h | 20h | 400 | 400 |
| 72 | 1.2.7.4 | 2.6.4 - Node | 10h | 2023-10-11 A | 2023-10-16 A | 43 | 100% |  |  | A_PI | 10h | 10h | 200 | 200 |
| 73 | 1.2.7.5 | 2.6.5 - Autoloader | 2h | 2023-10-06 A | 2023-10-06 A | 34 | 100% |  |  | A_PI | 2h | 2h | 40 | 40 |
| 74 | 1.2.7.6 | 2.6.6 - Composer | 2h | 2023-10-06 A | 2023-10-06 A | 34 | 100% |  |  | A_PI; D_DA | 2h | 2h | 40 | 40 |
| 75 | 1.2.7.7 | 2.6.7 - Architecture Repository | 30h? | 2023-10-06 A | 2023-10-20 A | 34 | 100% |  |  | A_PI; K_MO | 30h | 30h | 600 | 600 |
